# BEDs_schedule_2012

Schedule from MS Project, 2012-06-20 to 2012-12-19.

## Calendars

- Standard: Mon-Fri 08:00-12:00, 13:00-17:00; Sat-Sun off.

## Schedule

| ID | WBS | Task | Type | Duration | Start | Finish | Predecessors | Total slack |
| --- | --- | --- | --- | --- | --- | --- | --- | --- |
| 1 | 1 | **Software** |  | 112d | 2012-06-20 | 2012-11-22 |  | 0d |
| 2 | 1.1 | Integrate IMU | manual | 23d | 2012-06-20 | 2012-07-20 |  |  |
| 3 | 1.2 | Develop UI | manual | 30d | 2012-07-23 | 2012-08-31 | 2 |  |
| 4 | 1.3 | Test UI | manual | 15d | 2012-09-03 | 2012-09-21 | 3 |  |
| 5 | 1.4 | RTC integration | manual | 18d | 2012-09-24 | 2012-10-17 | 4 |  |
| 6 | 1.5 | Modem Integration | manual | 10d | 2012-10-18 | 2012-10-31 | 5 |  |
| 7 | 1.6 | Data formatting | manual | 5d | 2012-11-01 | 2012-11-07 | 6 |  |
| 8 | 1.7 | Board bringup | manual | 20d | 2012-10-26 | 2012-11-22 | 21 |  |
| 9 | 1.8 | **Sensor integration** |  | 20d | 2012-10-26 | 2012-11-22 |  | 0d |
| 10 | 1.8.1 | Environmental | manual | 5d | 2012-10-26 | 2012-11-01 | 21 |  |
| 11 | 1.8.2 | Load management | manual | 5d | 2012-11-02 | 2012-11-08 | 10 |  |
| 12 | 1.8.3 | A/D | manual | 5d | 2012-11-09 | 2012-11-15 | 11 |  |
| 13 | 1.8.4 | Pressure | manual | 5d | 2012-11-16 | 2012-11-22 | 12 |  |
| 14 | 2 | **Electrical** |  | 104d? | 2012-06-20 | 2012-11-12 |  | 0d |
| 15 | 2.1 | Final sensor selection | manual | 14d | 2012-06-20 | 2012-07-09 |  |  |
| 16 | 2.2 | Procure/assemble battery pack | manual | 1d? | 2012-06-20 | 2012-06-20 |  |  |
| 17 | 2.3 | Circuit design | manual | 45d | 2012-07-10 | 2012-09-10 | 15 |  |
| 18 | 2.4 | Circuit review | manual | 7d | 2012-09-11 | 2012-09-19 | 17 |  |
| 19 | 2.5 | Layout | manual | 10d | 2012-09-20 | 2012-10-03 | 18 |  |
| 20 | 2.6 | PCB Fabrication | manual | 10d | 2012-10-04 | 2012-10-17 | 19 |  |
| 21 | 2.7 | Initial board bringup | manual | 6d | 2012-10-18 | 2012-10-25 | 20 |  |
| 22 | 2.8 | Final board checkout | manual | 12d | 2012-10-26 | 2012-11-12 | 21 |  |
| 23 | 3 | **Mechanical** |  | 97d | 2012-07-10 | 2012-11-21 |  | 0d |
| 24 | 3.1 | Housing procurement | manual | 18d | 2012-07-10 | 2012-08-02 | 15 |  |
| 25 | 3.2 | Housing endcaps/machining | manual | 18d | 2012-08-03 | 2012-08-28 | 24 |  |
| 26 | 3.3 | Housing bracketry | manual | 10d | 2012-10-04 | 2012-10-17 | 19 |  |
| 27 | 3.4 | Housing assembly | manual | 7d | 2012-10-18 | 2012-10-26 | 26 |  |
| 28 | 3.5 | Sphere procurement | manual | 25d | 2012-07-10 | 2012-08-13 | 15 |  |
| 29 | 3.6 | Sphere machining | manual | 7d | 2012-08-29 | 2012-09-06 | 25 |  |
| 30 | 3.7 | Unpopulated Pressure/Ocean test? | manual | 5d | 2012-10-29 | 2012-11-02 | 27 |  |
| 31 | 3.8 | Integration/Assembly | manual | 7d | 2012-11-13 | 2012-11-21 | 14 |  |

| ID | WBS | Task | Type | Duration | Start | Finish | Predecessors | Total slack |
| --- | --- | --- | --- | --- | --- | --- | --- | --- |
| 32 | 4 | **Systems** |  | 94d | 2012-07-23 | 2012-11-29 |  | 0d |
| 33 | 4.1 | Test Motion thresholds | manual | 14d | 2012-07-23 | 2012-08-09 | 2 |  |
| 34 | 4.2 | RTC calibration | manual | 5d | 2012-10-26 | 2012-11-01 | 21 |  |
| 35 | 4.3 | Tethered shallow water tests | manual | 5d | 2012-11-23 | 2012-11-29 | 14, 1, 23, 31 |  |
| 36 | 5 | Deployment 1 | milestone, manual | 0d | 2012-11-30 | 2012-11-30 | 35 |  |
| 37 | 6 | **Operations** |  | 14d | 2012-11-30 | 2012-12-19 |  | 0d |
| 38 | 6.1 | Prototype Deployment | manual | 14d | 2012-11-30 | 2012-12-19 | 36 |  |
